# ReportResourcesPractice

How a schedule from MS Project changed from version to version. A marks actual dates.

## Version 1 (data date 2019-01-17, saved 2021-03-09, file CustomiseProjectPractice .mpp)

| ID | WBS | Task | Duration | Start | Finish | Predecessors | Total float |
| --- | --- | --- | --- | --- | --- | --- | --- |
| 1 | 1 | **Pre-work** | 3.5d | 2019-01-07 | 2019-01-10 |  | 0d |
| 2 |  | Get Fit-out quotes | 2d | 2019-01-07 | 2019-01-08 |  | 0d |
| 3 |  | Get Moving Company Quotes | 1d | 2019-01-09 | 2019-01-09 | 2FS-5% | 0d |
| 4 |  | Evaluate and Accept Quotes | 2h | 2019-01-10 | 2019-01-10 | 3 | 0d |
| 5 |  | Confirm Moving Day | 2h | 2019-01-10 | 2019-01-10 | 4 | 0d |
| 6 | 2 | **Fit Out New Premises** | 6.5d | 2019-01-10 | 2019-01-18 | 1 | 0d |
| 7 |  | Power | 0.5d | 2019-01-10 | 2019-01-10 |  | 0d |
| 8 |  | Cabling | 4d | 2019-01-11 | 2019-01-14 | 7 | 0d |
| 9 |  | Decorating | 1w | 2019-01-14 | 2019-01-18 | 8FS-1d | 0d |
| 10 | 3 | **Packing** | 5d | 2019-01-21 | 2019-01-27 | 6 | 0d |
| 11 |  | Get Boxes | 2d | 2019-01-21 | 2019-01-22 |  | 0d |
| 12 |  | Pack boxes | 1w | 2019-01-23 | 2019-01-27 | 11 | 0d |
| 13 |  | Make Inventory | 1w | 2019-01-23 | 2019-01-27 | 12SS | 0d |
| 14 |  | Transport Boxes | 1d | 2019-01-28 | 2019-01-28 | 10 | 0d |
| 15 | 5 | **Unpacking** | 5d | 2019-01-29 | 2019-02-04 | 14 | 0d |
| 16 |  | Unpack Boxes | 1w | 2019-01-29 | 2019-02-04 |  | 0d |
| 17 |  | Install Equipment | 1w | 2019-01-29 | 2019-02-04 | 16FF | 0d |
| 18 |  | Check Inventory | 1w | 2019-01-29 | 2019-02-04 | 17FF | 0d |
| 19 |  | Move In | 0d | 2019-02-04 | 2019-02-04 | 15 | 0d |

## Version 2 (data date 2019-01-28, saved 2024-03-28, file AssignResourcesPractice.mpp)

Last finish 2019-02-04 → 2025-02-06 (+2194d).

Changed:

| ID | Task | Start | Finish | Duration | Predecessors | Other |
| --- | --- | --- | --- | --- | --- | --- |
| 1 | **Pre-work** | 2019-01-07 → 2025-01-06 (+2191d) | 2019-01-10 → 2025-01-09 (+2191d) | 3.5d → 3.62d |  | baseline start 2003-01-06 → none; baseline finish 2003-01-09 → none |
| 2 | Get Fit-out quotes | 2019-01-07 → 2025-01-06 (+2191d) | 2019-01-08 → 2025-01-07 (+2191d) |  |  | resources Manager's PA → none; baseline start 2003-01-06 → none; baseline finish 2003-01-07 → none |
| 3 | Get Moving Company Quotes | 2019-01-09 → 2025-01-08 (+2191d) | 2019-01-09 → 2025-01-08 (+2191d) |  | 2FS-5% → 2 | resources Manager's PA [50%] → none; baseline start 2003-01-08 → none; baseline finish 2003-01-08 → none |
| 4 | Evaluate and Accept Quotes | 2019-01-10 → 2025-01-09 (+2191d) | 2019-01-10 → 2025-01-09 (+2191d) | 2h → 3h |  | resources Manager → none; baseline start 2003-01-09 → none; baseline finish 2003-01-09 → none |
| 5 | Confirm Moving Day | 2019-01-10 → 2025-01-09 (+2191d) | 2019-01-10 → 2025-01-09 (+2191d) |  |  | constraint none → finish no later than 2025-01-10; resources Manager's PA → none; baseline start 2003-01-09 → none; baseline finish 2003-01-09 → none |
| 6 | **Fit Out New Premises** | 2019-01-10 → 2025-01-09 (+2191d) | 2019-01-18 → 2025-01-21 (+2195d) | 6.5d → 7.5d |  | baseline start 2003-01-09 → none; baseline finish 2003-01-21 → none |
| 7 | Power | 2019-01-10 → 2025-01-09 (+2191d) | 2019-01-10 → 2025-01-10 (+2192d) |  |  | resources Techies → none; baseline start 2003-01-09 → none; baseline finish 2003-01-10 → none |
| 8 | Cabling | 2019-01-11 → 2025-01-10 (+2191d) | 2019-01-14 → 2025-01-16 (+2194d) |  |  | resources Techies [300%] → none; baseline start 2003-01-10 → none; baseline finish 2003-01-16 → none |
| 9 | Decorating | 2019-01-14 → 2025-01-14 (+2192d) | 2019-01-18 → 2025-01-21 (+2195d) |  | 8FS-1d → 8FS-5% | resources Decorators → none; baseline start 2003-01-14 → none; baseline finish 2003-01-21 → none |
| 10 | **Packing** | 2019-01-21 → 2025-01-21 (+2192d) | 2019-01-27 → 2025-01-29 (+2194d) | 5d → 6d |  | baseline start 2003-01-21 → none; baseline finish 2003-01-30 → none |
| 11 | Get Boxes | 2019-01-21 → 2025-01-21 (+2192d) | 2019-01-22 → 2025-01-22 (+2192d) | 2d → 1d |  | resources Boxes [20 Each]; Techies [200%] → none; baseline start 2003-01-21 → none; baseline finish 2003-01-22 → none |
| 12 | Pack boxes | 2019-01-23 → 2025-01-22 (+2191d) | 2019-01-27 → 2025-01-29 (+2194d) |  |  | resources Techies [300%] → none; baseline start 2003-01-22 → none; baseline finish 2003-01-30 → none |
| 13 | Make Inventory | 2019-01-23 → 2025-01-22 (+2191d) | 2019-01-27 → 2025-01-29 (+2194d) |  |  | resources Manager's PA → none; baseline start 2003-01-22 → none; baseline finish 2003-01-30 → none |
| 14 | Transport Boxes | 2019-01-28 → 2025-01-29 (+2193d) | 2019-01-28 → 2025-01-30 (+2194d) | 1d → 1ed |  | resources Moving Company → none; baseline start 2003-01-30 → none; baseline finish 2003-01-31 → none |
| 15 | **Unpacking** | 2019-01-29 → 2025-01-30 (+2193d) | 2019-02-04 → 2025-02-06 (+2194d) |  |  | baseline start 2003-01-31 → none; baseline finish 2003-02-10 → none |
| 16 | Unpack Boxes | 2019-01-29 → 2025-01-30 (+2193d) | 2019-02-04 → 2025-02-06 (+2194d) |  |  | resources Techies [150%] → none; baseline start 2003-01-31 → none; baseline finish 2003-02-10 → none |
| 17 | Install Equipment | 2019-01-29 → 2025-01-30 (+2193d) | 2019-02-04 → 2025-02-06 (+2194d) |  |  | resources Techies [150%] → none; baseline start 2003-01-31 → none; baseline finish 2003-02-10 → none |
| 18 | Check Inventory | 2019-01-29 → 2025-01-30 (+2193d) | 2019-02-04 → 2025-02-06 (+2194d) |  |  | resources Manager's PA → none; baseline start 2003-01-31 → none; baseline finish 2003-02-10 → none |
| 19 | Move In | 2019-02-04 → 2025-02-06 (+2194d) | 2019-02-04 → 2025-02-06 (+2194d) |  |  | baseline start 2003-02-10 → none; baseline finish 2003-02-10 → none |

## Version 3 (data date 2019-01-16, saved 2024-03-28, file AssortedTricksPractice.mpp)

Last finish stays 2025-02-06.

Changed:

| ID | Task | Duration | Predecessors | Other |
| --- | --- | --- | --- | --- |
| 1 | **Pre-work** | 3.62d → 3.75d |  |  |
| 2 | Get Fit-out quotes |  |  | resources none → Manager's PA |
| 3 | Get Moving Company Quotes |  | 2 → 2FS-5% | resources none → Manager's PA [50%] |
| 4 | Evaluate and Accept Quotes | 3h → 4h |  | resources none → Manager |
| 5 | Confirm Moving Day |  |  | constraint finish no later than 2025-01-10 → none; resources none → Manager's PA |
| 7 | Power |  |  | resources none → Techies |
| 8 | Cabling |  |  | resources none → Manager's PA [25%]; Techies [300%] |
| 9 | Decorating |  |  | resources none → Manager's PA [25%]; Decorators |
| 11 | Get Boxes |  |  | resources none → Boxes [20 Each]; Techies [200%] |
| 12 | Pack boxes |  |  | resources none → Techies [300%] |
| 13 | Make Inventory |  |  | resources none → Manager's PA |
| 14 | Transport Boxes | 1ed → 1d |  | resources none → Moving Company |
| 16 | Unpack Boxes |  |  | resources none → Techies [150%] |
| 17 | Install Equipment |  |  | resources none → Techies [150%] |
| 18 | Check Inventory |  |  | resources none → Manager's PA |

## Version 4 (data date 2019-01-28, saved 2024-03-28, file CreateResourcesPractice.mpp)

Last finish stays 2025-02-06.

Changed:

| ID | Task | Duration | Predecessors | Other |
| --- | --- | --- | --- | --- |
| 1 | **Pre-work** | 3.75d → 3.62d |  |  |
| 2 | Get Fit-out quotes |  |  | resources Manager's PA → none |
| 3 | Get Moving Company Quotes |  | 2FS-5% → 2 | resources Manager's PA [50%] → none |
| 4 | Evaluate and Accept Quotes | 4h → 3h |  | resources Manager → none |
| 5 | Confirm Moving Day |  |  | constraint none → finish no later than 2025-01-10; resources Manager's PA → none |
| 7 | Power |  |  | resources Techies → none |
| 8 | Cabling |  |  | resources Manager's PA [25%]; Techies [300%] → none |
| 9 | Decorating |  |  | resources Manager's PA [25%]; Decorators → none |
| 11 | Get Boxes |  |  | resources Boxes [20 Each]; Techies [200%] → none |
| 12 | Pack boxes |  |  | resources Techies [300%] → none |
| 13 | Make Inventory |  |  | resources Manager's PA → none |
| 14 | Transport Boxes | 1d → 1ed |  | resources Moving Company → none |
| 16 | Unpack Boxes |  |  | resources Techies [150%] → none |
| 17 | Install Equipment |  |  | resources Techies [150%] → none |
| 18 | Check Inventory |  |  | resources Manager's PA → none |

## Version 5 (data date 2019-01-12, saved 2024-03-28, file ExportPractice .mpp)

Last finish 2025-02-06 → 2025-02-03 (-3d).

Changed:

| ID | Task | Start | Finish | Duration | Predecessors | Other |
| --- | --- | --- | --- | --- | --- | --- |
| 1 | **Pre-work** |  |  | 3.62d → 3.5d |  | baseline start none → 2003-01-06; baseline finish none → 2003-01-09 |
| 2 | Get Fit-out quotes |  |  |  |  | resources none → Manager's PA; baseline start none → 2003-01-06; baseline finish none → 2003-01-07 |
| 3 | Get Moving Company Quotes |  |  |  | 2 → 2FS-5% | resources none → Manager's PA [50%]; baseline start none → 2003-01-08; baseline finish none → 2003-01-08 |
| 4 | Evaluate and Accept Quotes |  |  | 3h → 2h |  | resources none → Manager; baseline start none → 2003-01-09; baseline finish none → 2003-01-09 |
| 5 | Confirm Moving Day |  |  |  |  | constraint finish no later than 2025-01-10 → none; resources none → Manager's PA; baseline start none → 2003-01-09; baseline finish none → 2003-01-09 |
| 6 | **Fit Out New Premises** |  | 2025-01-21 → 2025-01-17 (-4d) | 7.5d → 6.5d |  | baseline start none → 2003-01-09; baseline finish none → 2003-01-21 |
| 7 | Power |  | 2025-01-10 → 2025-01-09 (-1d) |  |  | resources none → Techies; baseline start none → 2003-01-09; baseline finish none → 2003-01-10 |
| 8 | Cabling |  | 2025-01-16 → 2025-01-13 (-3d) |  |  | resources none → Techies [300%]; baseline start none → 2003-01-10; baseline finish none → 2003-01-16 |
| 9 | Decorating | 2025-01-14 → 2025-01-13 (-1d) | 2025-01-21 → 2025-01-17 (-4d) |  | 8FS-5% → 8FS-1d | resources none → Decorators; baseline start none → 2003-01-14; baseline finish none → 2003-01-21 |
| 10 | **Packing** | 2025-01-21 → 2025-01-20 (-1d) | 2025-01-29 → 2025-01-26 (-3d) | 6d → 5d |  | baseline start none → 2003-01-21; baseline finish none → 2003-01-30 |
| 11 | Get Boxes | 2025-01-21 → 2025-01-20 (-1d) | 2025-01-22 → 2025-01-21 (-1d) | 1d → 2d |  | resources none → Boxes [20 Each]; Techies [200%]; baseline start none → 2003-01-21; baseline finish none → 2003-01-22 |
| 12 | Pack boxes |  | 2025-01-29 → 2025-01-26 (-3d) |  |  | resources none → Techies [300%]; baseline start none → 2003-01-22; baseline finish none → 2003-01-30 |
| 13 | Make Inventory |  | 2025-01-29 → 2025-01-26 (-3d) |  |  | resources none → Manager's PA; baseline start none → 2003-01-22; baseline finish none → 2003-01-30 |
| 14 | Transport Boxes | 2025-01-29 → 2025-01-27 (-2d) | 2025-01-30 → 2025-01-27 (-3d) | 1ed → 1d |  | resources none → Moving Company; baseline start none → 2003-01-30; baseline finish none → 2003-01-31 |
| 15 | **Unpacking** | 2025-01-30 → 2025-01-28 (-2d) | 2025-02-06 → 2025-02-03 (-3d) |  |  | baseline start none → 2003-01-31; baseline finish none → 2003-02-10 |
| 16 | Unpack Boxes | 2025-01-30 → 2025-01-28 (-2d) | 2025-02-06 → 2025-02-03 (-3d) |  |  | resources none → Techies [150%]; baseline start none → 2003-01-31; baseline finish none → 2003-02-10 |
| 17 | Install Equipment | 2025-01-30 → 2025-01-28 (-2d) | 2025-02-06 → 2025-02-03 (-3d) |  |  | resources none → Techies [150%]; baseline start none → 2003-01-31; baseline finish none → 2003-02-10 |
| 18 | Check Inventory | 2025-01-30 → 2025-01-28 (-2d) | 2025-02-06 → 2025-02-03 (-3d) |  |  | resources none → Manager's PA; baseline start none → 2003-01-31; baseline finish none → 2003-02-10 |
| 19 | Move In | 2025-02-06 → 2025-02-03 (-3d) | 2025-02-06 → 2025-02-03 (-3d) |  |  | baseline start none → 2003-02-10; baseline finish none → 2003-02-10 |

## Version 6 (data date 2019-01-28, saved 2024-03-28, file OverallocationsPractice.mpp)

Last finish 2025-02-03 → 2025-02-04 (+1d).

Changed:

| ID | Task | Start | Finish | Duration | Total float | Predecessors | Other |
| --- | --- | --- | --- | --- | --- | --- | --- |
| 1 | **Pre-work** |  | 2025-01-09 → 2025-01-08 (-1d) | 3.5d → 2.44d |  |  | baseline start 2003-01-06 → none; baseline finish 2003-01-09 → none |
| 2 | Get Fit-out quotes |  |  | 2d → 1.82d |  |  | resources Manager's PA → Manager’s PA [110%]; baseline start 2003-01-06 → none; baseline finish 2003-01-07 → none |
| 3 | Get Moving Company Quotes | 2025-01-08 → 2025-01-06 (-2d) | 2025-01-08 → 2025-01-07 (-1d) |  |  | 2FS-5% → 2FS-1d | resources Manager's PA [50%] → Manager’s PA [50%]; baseline start 2003-01-08 → none; baseline finish 2003-01-08 → none |
| 4 | Evaluate and Accept Quotes | 2025-01-09 → 2025-01-07 (-2d) | 2025-01-09 → 2025-01-08 (-1d) | 2h → 3h |  |  | baseline start 2003-01-09 → none; baseline finish 2003-01-09 → none |
| 5 | Confirm Moving Day | 2025-01-09 → 2025-01-08 (-1d) | 2025-01-09 → 2025-01-08 (-1d) |  |  |  | constraint none → finish no later than 2025-01-10; resources Manager's PA → Manager’s PA; baseline start 2003-01-09 → none; baseline finish 2003-01-09 → none |
| 6 | **Fit Out New Premises** | 2025-01-09 → 2025-01-08 (-1d) |  | 6.5d → 7.5d |  |  | baseline start 2003-01-09 → none; baseline finish 2003-01-21 → none |
| 7 | Power | 2025-01-09 → 2025-01-08 (-1d) | 2025-01-09 → 2025-01-08 (-1d) |  |  |  | baseline start 2003-01-09 → none; baseline finish 2003-01-10 → none |
| 8 | Cabling | 2025-01-10 → 2025-01-08 (-2d) | 2025-01-13 → 2025-01-14 (+1d) |  |  |  | resources Techies [300%] → Manager’s PA [25%]; Techies [300%]; baseline start 2003-01-10 → none; baseline finish 2003-01-16 → none |
| 9 | Decorating | 2025-01-13 → 2025-01-10 (-3d) |  |  |  | 8FS-1d → 8FS-5% | resources Decorators → Manager’s PA [25%]; Techies; baseline start 2003-01-14 → none; baseline finish 2003-01-21 → none |
| 10 | **Packing** | 2025-01-20 → 2025-01-17 (-3d) | 2025-01-26 → 2025-01-27 (+1d) | 5d → 6d |  |  | baseline start 2003-01-21 → none; baseline finish 2003-01-30 → none |
| 11 | Get Boxes | 2025-01-20 → 2025-01-17 (-3d) | 2025-01-21 → 2025-01-20 (-1d) | 2d → 1d |  |  | baseline start 2003-01-21 → none; baseline finish 2003-01-22 → none |
| 12 | Pack boxes | 2025-01-22 → 2025-01-20 (-2d) | 2025-01-26 → 2025-01-27 (+1d) |  |  |  | baseline start 2003-01-22 → none; baseline finish 2003-01-30 → none |
| 13 | Make Inventory | 2025-01-22 → 2025-01-20 (-2d) | 2025-01-26 → 2025-01-27 (+1d) |  |  |  | resources Manager's PA → Manager’s PA; baseline start 2003-01-22 → none; baseline finish 2003-01-30 → none |
| 14 | Transport Boxes |  | 2025-01-27 → 2025-01-28 (+1d) |  |  |  | baseline start 2003-01-30 → none; baseline finish 2003-01-31 → none |
| 15 | **Unpacking** |  | 2025-02-03 → 2025-02-04 (+1d) |  |  |  | baseline start 2003-01-31 → none; baseline finish 2003-02-10 → none |
| 16 | Unpack Boxes |  |  | 1w → 0.75w | 0d → 1.25d |  | resources Techies [150%] → Techies [200%]; baseline start 2003-01-31 → none; baseline finish 2003-02-10 → none |
| 17 | Install Equipment |  |  | 1w → 0.75w | 0d → 1.25d |  | resources Techies [150%] → Techies [200%]; baseline start 2003-01-31 → none; baseline finish 2003-02-10 → none |
| 18 | Check Inventory |  | 2025-02-03 → 2025-02-04 (+1d) |  |  |  | resources Manager's PA → Manager’s PA; baseline start 2003-01-31 → none; baseline finish 2003-02-10 → none |
| 19 | Move In | 2025-02-03 → 2025-02-04 (+1d) | 2025-02-03 → 2025-02-04 (+1d) |  |  |  | baseline start 2003-02-10 → none; baseline finish 2003-02-10 → none |

## Version 7 (saved 2024-03-28, file MoveOfficeRelationships.mpp)

Last finish 2025-02-04 → 2025-01-10 (-25d).

Changed:

| ID | Task | Start | Finish | Duration | Total float | Predecessors | Other |
| --- | --- | --- | --- | --- | --- | --- | --- |
| 1 | **Pre-work** |  | 2025-01-08 → 2025-01-07 (-1d) | 2.44d → 2d |  |  |  |
| 2 | Get Fit-out quotes |  |  | 1.82d → 2d | 0d → none |  | resources Manager’s PA [110%] → none |
| 3 | Get Moving Company Quotes |  | 2025-01-07 → 2025-01-06 (-1d) |  | 0d → none | 2FS-1d → none | resources Manager’s PA [50%] → none |
| 4 | Evaluate and Accept Quotes | 2025-01-07 → 2025-01-06 (-1d) | 2025-01-08 → 2025-01-06 (-2d) |  | 0d → none | 3 → none | resources Manager → none |
| 5 | Confirm Moving Day | 2025-01-08 → 2025-01-06 (-2d) | 2025-01-08 → 2025-01-06 (-2d) |  | 0d → none | 4 → none | constraint finish no later than 2025-01-10 → none; resources Manager’s PA → none |
| 6 | **Fit Out New Premises** | 2025-01-08 → 2025-01-06 (-2d) | 2025-01-17 → 2025-01-10 (-7d) | 7.5d → 5d |  | 1 → none |  |
| 7 | Power | 2025-01-08 → 2025-01-06 (-2d) | 2025-01-08 → 2025-01-06 (-2d) |  | 0d → none |  | resources Techies → none |
| 8 | Cabling | 2025-01-08 → 2025-01-06 (-2d) | 2025-01-14 → 2025-01-09 (-5d) |  | 0d → none | 7 → none | resources Manager’s PA [25%]; Techies [300%] → none |
| 9 | Decorating | 2025-01-10 → 2025-01-06 (-4d) | 2025-01-17 → 2025-01-10 (-7d) |  | 0d → none | 8FS-5% → none | resources Manager’s PA [25%]; Techies → none |
| 10 | **Packing** | 2025-01-17 → 2025-01-06 (-11d) | 2025-01-27 → 2025-01-10 (-17d) | 6d → 5d |  | 6 → none |  |
| 11 | Get Boxes | 2025-01-17 → 2025-01-06 (-11d) | 2025-01-20 → 2025-01-06 (-14d) |  | 0d → none |  | resources Boxes [20 Each]; Techies [200%] → none |
| 12 | Pack boxes | 2025-01-20 → 2025-01-06 (-14d) | 2025-01-27 → 2025-01-10 (-17d) |  | 0d → none | 11 → none | resources Techies [300%] → none |
| 13 | Make Inventory | 2025-01-20 → 2025-01-06 (-14d) | 2025-01-27 → 2025-01-10 (-17d) |  | 0d → none | 12SS → none | resources Manager’s PA → none |
| 14 | Transport Boxes | 2025-01-27 → 2025-01-06 (-21d) | 2025-01-28 → 2025-01-07 (-21d) | 1d → 1ed | 0d → none | 10 → none | resources Moving Company → none |
| 15 | **Unpacking** | 2025-01-28 → 2025-01-06 (-22d) | 2025-02-04 → 2025-01-10 (-25d) |  |  | 14 → none |  |
| 16 | Unpack Boxes | 2025-01-28 → 2025-01-06 (-22d) | 2025-02-03 → 2025-01-10 (-24d) | 0.75w → 1w | 1.25d → none |  | resources Techies [200%] → none |
| 17 | Install Equipment | 2025-01-28 → 2025-01-06 (-22d) | 2025-02-03 → 2025-01-10 (-24d) | 0.75w → 1w | 1.25d → none | 16FF → none | resources Techies [200%] → none |
| 18 | Check Inventory | 2025-01-28 → 2025-01-06 (-22d) | 2025-02-04 → 2025-01-10 (-25d) |  | 0d → none | 17FF → none | resources Manager’s PA → none |
| 19 | Move In | 2025-02-04 → 2025-01-06 (-29d) | 2025-02-04 → 2025-01-06 (-29d) |  | 0d → none | 15 → none |  |

## Version 8 (saved 2024-03-28, file MoveOfficeTasks.mpp)

Last finish stays 2025-01-10.

Removed: 16 Unpack Boxes; 17 Install Equipment; 18 Check Inventory; 19 Move In

Changed:

| ID | Task | Finish | Duration | Total float |
| --- | --- | --- | --- | --- |
| 1 | Pre-work | 2025-01-07 → 2025-01-06 (-1d) | 2d → 1d | 0d → none |
| 6 | Fit Out New Premises | 2025-01-10 → 2025-01-06 (-4d) | 5d → 1d | 0d → none |
| 10 | Packing | 2025-01-10 → 2025-01-06 (-4d) | 5d → 1d | 0d → none |
| 15 | Unpacking | 2025-01-10 → 2025-01-06 (-4d) | 5d → 1d | 0d → none |

## Version 9 (saved 2024-03-28, file MoveOfficeTracking.mpp)

Last finish 2025-01-10 → 2025-02-20 (+41d).

Added:

| ID | Task | Duration | Start | Finish | Predecessors |
| --- | --- | --- | --- | --- | --- |
| 16 | Unpack Boxes | 1w | 2025-01-30 | 2025-02-06 |  |
| 17 | Install Equipment | 1w | 2025-02-06 | 2025-02-13 | 16 |
| 18 | Check Inventory | 1w | 2025-02-13 | 2025-02-20 | 17 |
| 19 | Move In | 0d | 2025-02-20 | 2025-02-20 | 15 |

Changed:

| ID | Task | Start | Finish | Duration | Total float | Predecessors | Other |
| --- | --- | --- | --- | --- | --- | --- | --- |
| 1 | **Pre-work** |  | 2025-01-06 → 2025-01-09 (+3d) | 1d → 3.62d | none → 0d |  |  |
| 3 | Get Moving Company Quotes | 2025-01-06 → 2025-01-08 (+2d) | 2025-01-06 → 2025-01-08 (+2d) |  | none → 0d | none → 2 |  |
| 4 | Evaluate and Accept Quotes | 2025-01-06 → 2025-01-09 (+3d) | 2025-01-06 → 2025-01-09 (+3d) |  | none → 0d | none → 3 |  |
| 5 | Confirm Moving Day | 2025-01-06 → 2025-01-09 (+3d) | 2025-01-06 → 2025-01-09 (+3d) |  | none → 0d | none → 4 | constraint none → finish no later than 2025-01-10 |
| 6 | **Fit Out New Premises** | 2025-01-06 → 2025-01-09 (+3d) | 2025-01-06 → 2025-01-21 (+15d) | 1d → 7.5d | none → 0d | none → 1 |  |
| 7 | Power | 2025-01-06 → 2025-01-09 (+3d) | 2025-01-06 → 2025-01-10 (+4d) |  | none → 0d |  |  |
| 8 | Cabling | 2025-01-06 → 2025-01-10 (+4d) | 2025-01-09 → 2025-01-16 (+7d) |  | none → 0d | none → 7 |  |
| 9 | Decorating | 2025-01-06 → 2025-01-14 (+8d) | 2025-01-10 → 2025-01-21 (+11d) |  | none → 0d | none → 8FS-5% |  |
| 10 | **Packing** | 2025-01-06 → 2025-01-21 (+15d) | 2025-01-06 → 2025-01-29 (+23d) | 1d → 6d | none → 0d | none → 6 |  |
| 11 | Get Boxes | 2025-01-06 → 2025-01-21 (+15d) | 2025-01-06 → 2025-01-22 (+16d) |  | none → 0d |  |  |
| 12 | Pack boxes | 2025-01-06 → 2025-01-22 (+16d) | 2025-01-10 → 2025-01-29 (+19d) |  | none → 0d | none → 11 |  |
| 13 | Make Inventory | 2025-01-06 → 2025-01-22 (+16d) | 2025-01-10 → 2025-01-29 (+19d) |  | none → 0d | none → 12SS |  |
| 14 | Transport Boxes | 2025-01-06 → 2025-01-29 (+23d) | 2025-01-07 → 2025-01-30 (+23d) |  | none → 0d | none → 10 |  |
| 15 | **Unpacking** | 2025-01-06 → 2025-01-30 (+24d) | 2025-01-06 → 2025-02-20 (+45d) | 1d → 15d | none → 0d | none → 14 |  |

## Version 10 (data date 2010-01-28, saved 2024-03-28, file ReportResourcesPractice.mpp)

Last finish 2025-02-20 → 2025-02-06 (-14d). Complete tasks 0 → 6.

Changed:

| ID | Task | Start | Finish | Duration | Complete | Total float | Predecessors | Other |
| --- | --- | --- | --- | --- | --- | --- | --- | --- |
| 1 | **Pre-work** | 2025-01-06 A | 2025-01-09 A |  | 0% → 100% | 0d → none |  | baseline start none → 2010-01-04; baseline finish none → 2010-01-07 |
| 2 | Get Fit-out quotes | 2025-01-06 A | 2025-01-07 A |  | 0% → 100% | 0d → none |  | resources none → Manager’s PA; baseline start none → 2010-01-04; baseline finish none → 2010-01-05 |
| 3 | Get Moving Company Quotes | 2025-01-08 A | 2025-01-08 A |  | 0% → 100% | 0d → none |  | resources none → Manager’s PA [50%]; baseline start none → 2010-01-06; baseline finish none → 2010-01-06 |
| 4 | Evaluate and Accept Quotes | 2025-01-09 A | 2025-01-09 A |  | 0% → 100% | 0d → none |  | resources none → Manager; baseline start none → 2010-01-07; baseline finish none → 2010-01-07 |
| 5 | Confirm Moving Day | 2025-01-09 A | 2025-01-09 A |  | 0% → 100% | 0d → none |  | constraint finish no later than 2025-01-10 → none; resources none → Manager’s PA; baseline start none → 2010-01-07; baseline finish none → 2010-01-07 |
| 6 | **Fit Out New Premises** | 2025-01-09 A |  |  | 0% → 47% |  |  | baseline start none → 2010-01-07; baseline finish none → 2010-01-19 |
| 7 | Power | 2025-01-09 A | 2025-01-10 A |  | 0% → 100% | 0d → none |  | resources none → Techies; baseline start none → 2010-01-07; baseline finish none → 2010-01-08 |
| 8 | Cabling | 2025-01-10 A | 2025-01-16 A |  | 0% → 100% | 0d → none |  | resources none → Manager’s PA [25%]; Techies [300%]; baseline start none → 2010-01-08; baseline finish none → 2010-01-14 |
| 9 | Decorating |  |  |  |  |  |  | resources none → Manager’s PA [25%]; Decorators; baseline start none → 2010-01-12; baseline finish none → 2010-01-19 |
| 10 | **Packing** |  |  |  |  |  |  | baseline start none → 2010-01-19; baseline finish none → 2010-01-27 |
| 11 | Get Boxes |  |  |  |  |  |  | resources none → Boxes [20 Each]; Techies [200%]; baseline start none → 2010-01-19; baseline finish none → 2010-01-20 |
| 12 | Pack boxes |  |  |  |  |  |  | resources none → Techies [300%]; baseline start none → 2010-01-20; baseline finish none → 2010-01-27 |
| 13 | Make Inventory |  |  |  |  |  |  | resources none → Manager’s PA; baseline start none → 2010-01-20; baseline finish none → 2010-01-27 |
| 14 | Transport Boxes |  |  | 1ed → 1d |  |  |  | resources none → Moving Company; baseline start none → 2010-01-27; baseline finish none → 2010-01-28 |
| 15 | **Unpacking** |  | 2025-02-20 → 2025-02-06 (-14d) | 15d → 5d |  |  |  | baseline start none → 2010-01-28; baseline finish none → 2010-02-04 |
| 16 | Unpack Boxes |  |  |  |  |  |  | resources none → Techies [150%]; baseline start none → 2010-01-28; baseline finish none → 2010-02-04 |
| 17 | Install Equipment | 2025-02-06 → 2025-01-30 (-7d) | 2025-02-13 → 2025-02-06 (-7d) |  |  |  | 16 → 16FF | resources none → Techies [150%]; baseline start none → 2010-01-28; baseline finish none → 2010-02-04 |
| 18 | Check Inventory | 2025-02-13 → 2025-01-30 (-14d) | 2025-02-20 → 2025-02-06 (-14d) |  |  |  | 17 → 17FF | resources none → Manager’s PA; baseline start none → 2010-01-28; baseline finish none → 2010-02-04 |
| 19 | Move In | 2025-02-20 → 2025-02-06 (-14d) | 2025-02-20 → 2025-02-06 (-14d) |  |  |  |  | baseline start none → 2010-02-04; baseline finish none → 2010-02-04 |

## Version 11 (data date 2019-01-28, saved 2024-03-28, file ResourceCostsPractice.mpp)

Last finish stays 2025-02-06. Complete tasks 6 → 0.

Changed:

| ID | Task | Start | Finish | Complete | Total float | Other |
| --- | --- | --- | --- | --- | --- | --- |
| 1 | **Pre-work** | 2025-01-06 A → 2025-01-06 | 2025-01-09 A → 2025-01-09 | 100% → 0% | none → 0d | baseline start 2010-01-04 → none; baseline finish 2010-01-07 → none |
| 2 | Get Fit-out quotes | 2025-01-06 A → 2025-01-06 | 2025-01-07 A → 2025-01-07 | 100% → 0% | none → 0d | baseline start 2010-01-04 → none; baseline finish 2010-01-05 → none |
| 3 | Get Moving Company Quotes | 2025-01-08 A → 2025-01-08 | 2025-01-08 A → 2025-01-08 | 100% → 0% | none → 0d | baseline start 2010-01-06 → none; baseline finish 2010-01-06 → none |
| 4 | Evaluate and Accept Quotes | 2025-01-09 A → 2025-01-09 | 2025-01-09 A → 2025-01-09 | 100% → 0% | none → 0d | baseline start 2010-01-07 → none; baseline finish 2010-01-07 → none |
| 5 | Confirm Moving Day | 2025-01-09 A → 2025-01-09 | 2025-01-09 A → 2025-01-09 | 100% → 0% | none → 0d | constraint none → finish no later than 2025-01-10; baseline start 2010-01-07 → none; baseline finish 2010-01-07 → none |
| 6 | **Fit Out New Premises** | 2025-01-09 A → 2025-01-09 |  | 47% → 0% |  | baseline start 2010-01-07 → none; baseline finish 2010-01-19 → none |
| 7 | Power | 2025-01-09 A → 2025-01-09 | 2025-01-10 A → 2025-01-10 | 100% → 0% | none → 0d | baseline start 2010-01-07 → none; baseline finish 2010-01-08 → none |
| 8 | Cabling | 2025-01-10 A → 2025-01-10 | 2025-01-16 A → 2025-01-16 | 100% → 0% | none → 0d | baseline start 2010-01-08 → none; baseline finish 2010-01-14 → none |
| 9 | Decorating |  |  |  |  | baseline start 2010-01-12 → none; baseline finish 2010-01-19 → none |
| 10 | **Packing** |  |  |  |  | baseline start 2010-01-19 → none; baseline finish 2010-01-27 → none |
| 11 | Get Boxes |  |  |  |  | baseline start 2010-01-19 → none; baseline finish 2010-01-20 → none |
| 12 | Pack boxes |  |  |  |  | baseline start 2010-01-20 → none; baseline finish 2010-01-27 → none |
| 13 | Make Inventory |  |  |  |  | baseline start 2010-01-20 → none; baseline finish 2010-01-27 → none |
| 14 | Transport Boxes |  |  |  |  | baseline start 2010-01-27 → none; baseline finish 2010-01-28 → none |
| 15 | **Unpacking** |  |  |  |  | baseline start 2010-01-28 → none; baseline finish 2010-02-04 → none |
| 16 | Unpack Boxes |  |  |  |  | baseline start 2010-01-28 → none; baseline finish 2010-02-04 → none |
| 17 | Install Equipment |  |  |  |  | baseline start 2010-01-28 → none; baseline finish 2010-02-04 → none |
| 18 | Check Inventory |  |  |  |  | baseline start 2010-01-28 → none; baseline finish 2010-02-04 → none |
| 19 | Move In |  |  |  |  | baseline start 2010-02-04 → none; baseline finish 2010-02-04 → none |

## Version 12 (data date 2019-01-07, saved 2024-03-28, file SharedProject1Practice.mpp)

Last finish stays 2025-02-06.

Changed:

| ID | Task | Other |
| --- | --- | --- |
| 2 | Get Fit-out quotes | resources Manager’s PA → none |
| 3 | Get Moving Company Quotes | resources Manager’s PA [50%] → none |
| 4 | Evaluate and Accept Quotes | resources Manager → none |
| 5 | Confirm Moving Day | constraint finish no later than 2025-01-10 → none; resources Manager’s PA → none |
| 7 | Power | resources Techies → none |
| 8 | Cabling | resources Manager’s PA [25%]; Techies [300%] → none |
| 9 | Decorating | resources Manager’s PA [25%]; Decorators → none |
| 11 | Get Boxes | resources Boxes [20 Each]; Techies [200%] → none |
| 12 | Pack boxes | resources Techies [300%] → none |
| 13 | Make Inventory | resources Manager’s PA → none |
| 14 | Transport Boxes | resources Moving Company → none |
| 16 | Unpack Boxes | resources Techies [150%] → none |
| 17 | Install Equipment | resources Techies [150%] → none |
| 18 | Check Inventory | resources Manager’s PA → none |

## Version 13 (data date 2019-01-31, saved 2024-03-28, file MoveOfficeReporting.mpp)

Last finish 2025-02-06 → 2025-02-20 (+14d). Complete tasks 0 → 10.

Changed:

| ID | Task | Start | Finish | Duration | Complete | Total float | Predecessors | Other |
| --- | --- | --- | --- | --- | --- | --- | --- | --- |
| 1 | **Pre-work** | 2025-01-06 A | 2025-01-09 → 2025-01-13 A (+4d) | 3.62d → 5.25d | 0% → 100% | 0d → none |  | baseline start none → 2025-01-06; baseline finish none → 2025-01-09 |
| 2 | Get Fit-out quotes | 2025-01-06 A | 2025-01-07 A |  | 0% → 100% | 0d → none |  | baseline start none → 2025-01-06; baseline finish none → 2025-01-07 |
| 3 | Get Moving Company Quotes | 2025-01-08 A | 2025-01-08 A |  | 0% → 100% | 0d → none |  | baseline start none → 2025-01-08; baseline finish none → 2025-01-08 |
| 4 | Evaluate and Accept Quotes | 2025-01-09 A | 2025-01-09 A | 3h → 5h | 0% → 100% | 0d → none |  | baseline start none → 2025-01-09; baseline finish none → 2025-01-09 |
| 5 | Confirm Moving Day | 2025-01-09 → 2025-01-13 A (+4d) | 2025-01-09 → 2025-01-13 A (+4d) |  | 0% → 100% | 0d → none |  | constraint none → finish no later than 2025-01-10; baseline start none → 2025-01-09; baseline finish none → 2025-01-09 |
| 6 | **Fit Out New Premises** | 2025-01-09 → 2025-01-13 A (+4d) | 2025-01-21 A | 7.5d → 7d | 0% → 100% | 0d → none |  | baseline start none → 2025-01-09; baseline finish none → 2025-01-21 |
| 7 | Power | 2025-01-09 → 2025-01-13 A (+4d) | 2025-01-10 → 2025-01-13 A (+3d) |  | 0% → 100% | 0d → none |  | baseline start none → 2025-01-09; baseline finish none → 2025-01-10 |
| 8 | Cabling | 2025-01-10 → 2025-01-13 A (+3d) | 2025-01-16 A |  | 0% → 100% | 0d → none |  | baseline start none → 2025-01-10; baseline finish none → 2025-01-16 |
| 9 | Decorating | 2025-01-14 → 2025-01-15 A (+1d) | 2025-01-21 A |  | 0% → 100% | 0d → none |  | baseline start none → 2025-01-14; baseline finish none → 2025-01-21 |
| 10 | **Packing** | 2025-01-21 → 2025-01-22 A (+1d) | 2025-01-29 A |  | 0% → 100% | 0d → none |  | baseline start none → 2025-01-21; baseline finish none → 2025-01-29 |
| 11 | Get Boxes | 2025-01-21 → 2025-01-22 A (+1d) | 2025-01-22 A |  | 0% → 100% | 0d → none |  | baseline start none → 2025-01-21; baseline finish none → 2025-01-22 |
| 12 | Pack boxes | 2025-01-22 → 2025-01-23 A (+1d) | 2025-01-29 A |  | 0% → 100% | 0d → none |  | baseline start none → 2025-01-22; baseline finish none → 2025-01-29 |
| 13 | Make Inventory | 2025-01-22 → 2025-01-23 A (+1d) | 2025-01-29 A |  | 0% → 100% | 0d → none |  | baseline start none → 2025-01-22; baseline finish none → 2025-01-29 |
| 14 | Transport Boxes | 2025-01-29 → 2025-01-30 A (+1d) | 2025-01-30 → 2025-01-31 (+1d) | 1d → 1ed | 0% → 8% |  |  | baseline start none → 2025-01-29; baseline finish none → 2025-01-30 |
| 15 | **Unpacking** | 2025-01-30 → 2025-01-31 (+1d) | 2025-02-06 → 2025-02-20 (+14d) | 5d → 15d |  |  |  | baseline start none → 2025-01-30; baseline finish none → 2025-02-20 |
| 16 | Unpack Boxes | 2025-01-30 → 2025-01-31 (+1d) |  |  |  |  |  | baseline start none → 2025-01-30; baseline finish none → 2025-02-06 |
| 17 | Install Equipment | 2025-01-30 → 2025-02-07 (+8d) | 2025-02-06 → 2025-02-13 (+7d) |  |  |  | 16FF → 16 | baseline start none → 2025-02-06; baseline finish none → 2025-02-13 |
| 18 | Check Inventory | 2025-01-30 → 2025-02-14 (+15d) | 2025-02-06 → 2025-02-20 (+14d) |  |  |  | 17FF → 17 | baseline start none → 2025-02-13; baseline finish none → 2025-02-20 |
| 19 | Move In | 2025-02-06 → 2025-02-20 (+14d) | 2025-02-06 → 2025-02-20 (+14d) |  |  |  |  | baseline start none → 2025-02-20; baseline finish none → 2025-02-20 |
